# MICEMagFieldMitigation

Schedule from MS Project, 2012-10-22 to 2014-06-04.
STFC

## Calendars

- Standard: Mon-Fri 08:00-12:00, 13:00-17:00; Sat-Sun off.

## Resources

| Resource |
| --- |
| JT |
| IM |
| VF |
| TW |
| CM |
| DA |
| PS |
| MC |
| CP |
| All |
| LF |
| TB |
| DP |
| OPUS |
| BPG |
| K-R |
| CMc |
| ISIS |
| Hall |
| JG |
| JW |
| OM |
| ? |
| Contractor |
| Modellers |
| Jason |
| Craig |
| Groups |
| Luke |
| Paul |
| Melissa |
| Kiril |
| Craig & others |
| Craig/Luke |
| Melissa & others |
| Others |
| Geoff? |
| Steves Grad 6M |
| Geoff |
| Mag Shields |
| Regal |
| Kier |
| Cyclone |
| Rlamb' |
| Hnebr' |
| AG |
| Holger |
| Mike |
| Vicky? |
| Vicky |
| Victoria |
| Ian |
| Celeste? |
| Celeste |
| Steve Grad 6M 50%? |
| Modeller |
| MG |
| Test |
| Design |
| KM |
| C< |

## Schedule

| ID | WBS | Task | Type | Duration | Start | Finish | Predecessors | Total slack | Free slack | Constraint | Resources | Work |
| --- | --- | --- | --- | --- | --- | --- | --- | --- | --- | --- | --- | --- |
| 1 | 1 | **MICE Magnetic Field Mitigation** |  | 423d? | 2012-10-22 | 2014-06-04 |  | 0d |  |  |  | 20912h |
| 2 | 1.1 | **Hall Model & Validation** |  | 79d | 2013-01-30 | 2013-05-20 |  | 272d |  |  |  | 992h |
| 3 | 1.1.1 | Biot Savart verification |  | 10d | 2013-02-12 | 2013-02-25 |  | 272d | 0d |  | PS | 80h |
| 4 | 1.1.2 | Resolution investigation |  | 20d | 2013-02-26 | 2013-03-25 | 3 | 272d | 0d |  | PS | 160h |
| 5 | 1.1.3 | Further develop hall model |  | 40d | 2013-03-26 | 2013-05-20 | 4 | 272d |  | start no earlier than 2012-07-16 | PS | 320h |
| 6 | 1.1.4 | Hall AFC only model for verification |  | 5d | 2013-02-12 | 2013-02-18 |  | 313d | 0d |  | PS | 40h |
| 7 | 1.1.5 | Hall AFC field testing |  | 10d | 2013-02-19 | 2013-03-04 | 6 | 327d |  |  | Test | 80h |
| 8 | 1.1.6 | Measure AFC field in R9 & compare to model |  | 5d | 2013-02-12 | 2013-02-18 |  | 337d |  |  | Test | 40h |
| 9 | 1.1.7 | Learn & Design rack/compressor item and use in R9 AFC model |  | 30d | 2013-01-30 | 2013-03-12 |  | 306d | 0d | start no earlier than 2013-01-30 | MG | 240h |
| 10 | 1.1.8 | Measure AFC rack/compressor field in R9 & compare to model |  | 2d | 2013-03-13 | 2013-03-14 | 9 | 319d |  |  | Test | 16h |
| 11 | 1.1.9 | Sub-model validation? |  | 2d | 2013-02-12 | 2013-02-13 |  | 340d |  |  | Modeller | 16h |
| 12 | 1.2 | **West Wall Mezz & Compressors** |  | 229d? | 2013-01-28 | 2013-12-12 |  | 124d |  |  |  | 14176h |
| 13 | 1.2.1 | **Magnetic Modelling at West wall** |  | 40d | 2013-01-28 | 2013-03-22 |  | 152d |  |  |  | 320h |
| 14 | 1.2.1.1 | Modelling & results |  | 30d | 2013-01-28 | 2013-03-08 |  | 152d | 0d | start no earlier than 2013-01-28 | PS | 240h |
| 15 | 1.2.1.2 | Cross checking |  | 10d | 2013-03-11 | 2013-03-22 | 14 | 152d | 0d |  | MC | 80h |
| 16 | 1.2.1.3 | TB approval & sign off | milestone | 0d | 2013-03-22 | 2013-03-22 | 15 | 152d | 0d |  | All |  |
| 17 | 1.2.2 | **Shielding Required? DEPENDS ON ANALYSIS** |  | 146d? | 2013-03-25 | 2013-10-14 |  | 152d |  |  |  | 1568h |
| 18 | 1.2.2.1 | Concept Design |  | 15d | 2013-03-25 | 2013-04-12 | 16 | 152d | 0d |  | Mag Shields; JT | 240h |
| 19 | 1.2.2.2 | RFQ |  | 10d | 2013-04-15 | 2013-04-26 | 18 | 152d | 0d |  | JT | 80h |
| 20 | 1.2.2.3 | Order |  | 5d | 2013-04-29 | 2013-05-03 | 19 | 152d | 0d |  | JT | 40h |
| 21 | 1.2.2.4 | Final Design |  | 30d | 2013-05-06 | 2013-06-14 | 20 | 152d | 0d |  | Mag Shields; JT | 480h |
| 22 | 1.2.2.5 | Review & Iteration |  | 5d | 2013-06-17 | 2013-06-21 | 21 | 152d | 0d |  | Mag Shields; JT | 80h |
| 23 | 1.2.2.6 | Manufacture |  | 80d | 2013-06-24 | 2013-10-11 | 22 | 152d | 0d |  | Mag Shields | 640h |
| 24 | 1.2.2.7 | Acceptance & Test |  | 1d? | 2013-10-14 | 2013-10-14 | 23 | 152d | 0d |  | JT | 8h |
| 25 | 1.2.2.8 | Sign Off / Complete | milestone | 0d | 2013-10-14 | 2013-10-14 | 24 | 152d | 0d |  | JT |  |

| ID | WBS | Task | Type | Duration | Start | Finish | Predecessors | Total slack | Free slack | Constraint | Resources | Work |
| --- | --- | --- | --- | --- | --- | --- | --- | --- | --- | --- | --- | --- |
| 26 | 1.2.3 | **Design** |  | 58d | 2013-01-28 | 2013-04-17 |  | 124d |  |  |  | 2064h |
| 27 | 1.2.3.1 | West Wall Mezzanine Concept |  | 10d | 2013-01-28 | 2013-02-08 |  | 124d | 0d | start no earlier than 2013-01-28 | JT | 80h |
| 28 | 1.2.3.2 | Approval (SHE, TB) |  | 5d | 2013-02-11 | 2013-02-15 | 27 | 124d | 0d |  | JT | 40h |
| 29 | 1.2.3.3 | Complete | milestone | 0d | 2013-02-15 | 2013-02-15 | 28 | 124d | 0d |  |  |  |
| 30 | 1.2.3.4 | **Opus Installation Drawings** |  | 43d | 2013-02-18 | 2013-04-17 |  | 130d |  |  |  | 504h |
| 31 | 1.2.3.4.1 | RFQ |  | 10d | 2013-02-18 | 2013-03-01 | 29 | 130d | 0d |  | JT; DP | 160h |
| 32 | 1.2.3.4.2 | Order |  | 3d | 2013-03-04 | 2013-03-06 | 31 | 130d | 0d |  | DP | 24h |
| 33 | 1.2.3.4.3 | Design |  | 20d | 2013-03-07 | 2013-04-03 | 32 | 130d | 0d |  | OPUS | 160h |
| 34 | 1.2.3.4.4 | Review & Iteration |  | 10d | 2013-04-04 | 2013-04-17 | 33 | 130d | 0d |  | JT; DP | 160h |
| 35 | 1.2.3.4.5 | Sign Off / Complete | milestone | 0d | 2013-04-17 | 2013-04-17 | 34 | 130d | 0d |  | JT; DP |  |
| 36 | 1.2.3.5 | **Detail Design** |  | 30d | 2013-02-18 | 2013-03-29 |  | 124d |  |  |  | 1440h |
| 37 | 1.2.3.5.1 | Hose routing hardware (cable trays & tidy) |  | 30d | 2013-02-18 | 2013-03-29 | 29 | 180d | 0d |  | JW; IM; JT | 720h |
| 38 | 1.2.3.5.2 | Compressor support stands |  | 30d | 2013-02-18 | 2013-03-29 | 29 | 255d | 131d |  | JW; IM | 480h |
| 39 | 1.2.3.5.3 | South mezz stairs |  | 30d | 2013-02-18 | 2013-03-29 | 29 | 124d | 0d |  | BPG | 240h |
| 40 | 1.2.4 | **West Mezz Build & Associated** |  | 62d | 2013-04-18 | 2013-07-12 |  | 130d |  |  |  | 592h |
| 41 | 1.2.4.1 | RFQs |  | 10d | 2013-04-18 | 2013-05-01 | 35 | 130d | 0d |  | JT; DP | 160h |
| 42 | 1.2.4.2 | Orders |  | 5d | 2013-05-02 | 2013-05-08 | 16, 41 | 130d | 0d |  | DP | 40h |
| 43 | 1.2.4.3 | Contractor Start Date |  | 30d | 2013-05-09 | 2013-06-19 | 42 | 130d | 0d |  | BPG | 240h |
| 44 | 1.2.4.4 | Installation |  | 15d | 2013-06-20 | 2013-07-10 | 43, 82, 62 | 130d | 0d |  | Regal | 120h |
| 45 | 1.2.4.5 | Load Test? Inspection |  | 2d | 2013-07-11 | 2013-07-12 | 44 | 130d | 0d |  | JT; DP | 32h |
| 46 | 1.2.4.6 | Sign Off / Complete | milestone | 0d | 2013-07-12 | 2013-07-12 | 45 | 130d | 0d |  | JT; DP |  |
| 47 | 1.2.5 | **Related Hall Modifications** |  | 146d | 2013-02-18 | 2013-09-09 |  | 124d |  |  |  | 4664h |
| 48 | 1.2.5.1 | **PPS** |  | 140d | 2013-02-18 | 2013-08-30 |  | 130d |  |  |  | 776h |
| 49 | 1.2.5.1.1 | Design |  | 5d | 2013-02-18 | 2013-02-22 | 29 | 208d | 0d |  | CMc | 40h |
| 50 | 1.2.5.1.2 | Approval |  | 2d | 2013-02-25 | 2013-02-26 | 49 | 208d | 0d |  | ISIS | 16h |
| 51 | 1.2.5.1.3 | Purchase |  | 20d | 2013-02-27 | 2013-03-26 | 50 | 208d | 78d |  | CMc | 160h |
| 52 | 1.2.5.1.4 | Installation (incl. fence move) |  | 30d | 2013-07-15 | 2013-08-23 | 46, 51 | 130d | 0d |  | CMc; Hall | 480h |
| 53 | 1.2.5.1.5 | Commisioning Test and Approval |  | 5d | 2013-08-26 | 2013-08-30 | 52 | 130d | 6d |  | CMc; ISIS | 80h |

| ID | WBS | Task | Type | Duration | Start | Finish | Predecessors | Total slack | Free slack | Resources | Work |
| --- | --- | --- | --- | --- | --- | --- | --- | --- | --- | --- | --- |
| 54 | 1.2.5.2 | **South Mezz A/C** |  | 41d | 2013-02-18 | 2013-04-15 |  | 177d |  |  | 488h |
| 55 | 1.2.5.2.1 | Specification |  | 5d | 2013-02-18 | 2013-02-22 | 29 | 177d | 0d | JG | 40h |
| 56 | 1.2.5.2.2 | RFQ |  | 5d | 2013-02-25 | 2013-03-01 | 55 | 177d | 0d | JG | 40h |
| 57 | 1.2.5.2.3 | Order |  | 3d | 2013-03-04 | 2013-03-06 | 56 | 177d | 0d | JG | 24h |
| 58 | 1.2.5.2.4 | Move & Rotate A/C |  | 2d | 2013-03-07 | 2013-03-08 | 57 | 177d | 0d | JG | 16h |
| 59 | 1.2.5.2.5 | Rotate Vent (Contactor) |  | 20d | 2013-03-11 | 2013-04-05 | 58 | 177d | 0d | ?; JG | 320h |
| 60 | 1.2.5.2.6 | Reconnect |  | 5d | 2013-04-08 | 2013-04-12 | 59 | 177d | 0d | JG | 40h |
| 61 | 1.2.5.2.7 | Test |  | 1d | 2013-04-15 | 2013-04-15 | 60 | 177d | 0d | JG | 8h |
| 62 | 1.2.5.2.8 | Sign Off / Complete | milestone | 0d | 2013-04-15 | 2013-04-15 | 61 | 177d | 47d | JG |  |
| 63 | 1.2.5.3 | **Modification of South Mezz Stairs** |  | 116d | 2013-04-01 | 2013-09-09 |  | 124d |  |  | 1736h |
| 64 | 1.2.5.3.1 | RFQs (Manufacture & Installation) |  | 10d | 2013-04-01 | 2013-04-12 | 39 | 124d | 0d | BPG | 80h |
| 65 | 1.2.5.3.2 | Orders |  | 5d | 2013-04-15 | 2013-04-19 | 64 | 124d | 0d | BPG | 40h |
| 66 | 1.2.5.3.3 | Manufacture Lower Stair Section |  | 60d | 2013-04-22 | 2013-07-12 | 65 | 124d | 0d | BPG; Kier | 960h |
| 67 | 1.2.5.3.4 | Contractor Start Date |  | 30d | 2013-07-15 | 2013-08-23 | 66 | 124d | 0d | BPG; Kier | 480h |
| 68 | 1.2.5.3.5 | Cut (non-shield) Wall |  | 3d | 2013-08-26 | 2013-08-28 | 67 | 124d | 0d | BPG; Kier | 48h |
| 69 | 1.2.5.3.6 | Cut Existing Stairs |  | 3d | 2013-08-29 | 2013-09-02 | 68 | 124d | 0d | BPG; Kier | 48h |
| 70 | 1.2.5.3.7 | Fit Lower Stair Section |  | 5d | 2013-09-03 | 2013-09-09 | 69 | 124d | 0d | BPG; Kier | 80h |
| 71 | 1.2.5.3.8 | Sign off / Complete | milestone | 0d | 2013-09-09 | 2013-09-09 | 70 | 124d | 0d | BPG; JT |  |
| 72 | 1.2.5.4 | **Modification of Crane** |  | 53d | 2013-02-18 | 2013-05-01 |  | 217d |  |  | 664h |
| 73 | 1.2.5.4.1 | Concept Design |  | 5d | 2013-02-18 | 2013-02-22 | 29 | 217d | 0d | BPG | 40h |
| 74 | 1.2.5.4.2 | RFQ |  | 5d | 2013-02-25 | 2013-03-01 | 73 | 217d | 0d | BPG | 40h |
| 75 | 1.2.5.4.3 | Order |  | 3d | 2013-03-04 | 2013-03-06 | 74 | 217d | 0d | BPG | 24h |
| 76 | 1.2.5.4.4 | Contractor Start Date |  | 30d | 2013-03-07 | 2013-04-17 | 75 | 217d | 0d | BPG; Cyclone | 480h |
| 77 | 1.2.5.4.5 | Move Small Crane to Opposite Spar |  | 10d | 2013-04-18 | 2013-05-01 | 76 | 217d | 0d | Cyclone | 80h |
| 78 | 1.2.5.4.6 | Sign off / Complete | milestone | 0d | 2013-05-01 | 2013-05-01 | 77 | 217d | 93d | BPG |  |

| ID | WBS | Task | Type | Duration | Start | Finish | Predecessors | Total slack | Free slack | Constraint | Resources | Work |
| --- | --- | --- | --- | --- | --- | --- | --- | --- | --- | --- | --- | --- |
| 79 | 1.2.5.5 | **Existing West Wall Services** |  | 60d | 2013-02-18 | 2013-05-10 |  | 158d |  |  |  | 1000h |
| 80 | 1.2.5.5.1 | Fire Alarm System |  | 60d | 2013-02-18 | 2013-05-10 | 29 | 158d | 0d |  | BPG; Rlamb' | 960h |
| 81 | 1.2.5.5.2 | Web Cam |  | 5d | 2013-02-18 | 2013-02-22 | 29 | 213d | 55d |  | Hnebr' | 40h |
| 82 | 1.2.5.5.3 | Sign Off / Complete | milestone | 0d | 2013-05-10 | 2013-05-10 | 80, 81 | 158d | 28d |  | JT |  |
| 83 | 1.2.5.6 | Hall Modifications Complete | milestone | 0d | 2013-09-09 | 2013-09-09 | 53, 62, 71, 78, 82 | 124d | 0d |  |  |  |
| 84 | 1.2.6 | **Compressor Services (infrastructure)** |  | 118d | 2013-02-18 | 2013-07-31 |  | 182d |  |  |  | 2944h |
| 85 | 1.2.6.1 | Decision for water services location |  | 50d | 2013-02-18 | 2013-04-26 | 29 | 232d | 65d |  | All | 400h |
| 86 | 1.2.6.2 | Test Run of South Mezz compressors? | milestone | 0d | 2013-03-01 | 2013-03-01 |  | 248d | 0d | start no earlier than 2013-03-01 | ? |  |
| 87 | 1.2.6.3 | Redesign of services for west wall |  | 30d | 2013-02-18 | 2013-03-29 | 29 | 182d | 0d |  | IM; JW | 480h |
| 88 | 1.2.6.4 | Purchase of new services |  | 60d | 2013-04-01 | 2013-06-21 | 87 | 182d | 15d |  | IM; JW; Hall | 1440h |
| 89 | 1.2.6.5 | Move power distribution to West Mezz height |  | 15d | 2013-03-01 | 2013-03-21 | 29, 86 | 248d | 81d |  | IM; JW; Hall | 360h |
| 90 | 1.2.6.6 | Compressor power installation (wall only) |  | 5d | 2013-07-15 | 2013-07-19 | 46, 88, 89 | 167d | 0d |  | IM; JW; Hall | 120h |
| 91 | 1.2.6.7 | Compressor / Vacuum control rack |  | 5d | 2013-07-22 | 2013-07-26 | 90 | 167d | 0d |  | IM; JW; Hall | 120h |
| 92 | 1.2.6.8 | Compressor water services (incl trench?) |  | 3d | 2013-07-29 | 2013-07-31 | 85, 91 | 167d | 0d |  | JG | 24h |
| 93 | 1.2.6.9 | Sign Off / Complete | milestone | 0d | 2013-07-31 | 2013-07-31 | 92 | 220d |  |  |  |  |
| 94 | 1.2.7 | **Compressor & Services (feed) Support** |  | 156d | 2013-04-01 | 2013-11-04 | 27 | 152d |  |  |  | 1320h |
| 95 | 1.2.7.1 | Manufacture - purchase of parts |  | 60d | 2013-04-01 | 2013-06-21 | 29, 37 | 180d | 56d |  | JT; OM | 960h |
| 96 | 1.2.7.2 | Install Hose - Power Management Cable trays |  | 5d | 2013-09-10 | 2013-09-16 | 46, 83, 95 | 124d | 0d |  | Hall | 40h |
| 97 | 1.2.7.3 | Install Hose - Power Management Cable 'Tidy' |  | 5d | 2013-09-17 | 2013-09-23 | 96 | 124d | 0d |  | Hall | 40h |
| 98 | 1.2.7.4 | Install Fans under Compressor Positions (?) |  | 5d | 2013-09-24 | 2013-09-30 | 97 | 124d | 0d |  | Hall | 40h |
| 99 | 1.2.7.5 | Install Compressor Supports |  | 5d | 2013-10-01 | 2013-10-07 | 38, 92, 98 | 124d | 0d |  | Hall | 40h |
| 100 | 1.2.7.6 | Wire Up Isolators in Stands |  | 10d | 2013-10-08 | 2013-10-21 | 99 | 124d | 0d |  | Hall | 80h |
| 101 | 1.2.7.7 | Install Shielding (?) DEPENDS ON ANALYSIS |  | 15d | 2013-10-15 | 2013-11-04 | 25 | 152d |  |  | Hall | 120h |
| 102 | 1.2.7.8 | Sign Off / Complete | milestone | 0d | 2013-10-21 | 2013-10-21 | 100 | 124d | 0d |  | JT |  |

| ID | WBS | Task | Type | Duration | Start | Finish | Predecessors | Total slack | Free slack | Constraint | Resources | Work |
| --- | --- | --- | --- | --- | --- | --- | --- | --- | --- | --- | --- | --- |
| 103 | 1.2.8 | **Compressor Installation & Commisioning** |  | 214d | 2013-02-18 | 2013-12-12 |  | 124d |  |  |  | 704h |
| 104 | 1.2.8.1 | Purchase Scissor Jack Trolley |  | 40d | 2013-02-18 | 2013-04-12 | 29 | 220d | 0d |  | JT | 320h |
| 105 | 1.2.8.2 | Make Top for Trolley |  | 40d | 2013-04-15 | 2013-06-07 | 104 | 220d | 96d |  |  |  |
| 106 | 1.2.8.3 | Install Compressors |  | 10d | 2013-10-22 | 2013-11-04 | 100, 102, 105 | 124d | 0d |  | Hall | 80h |
| 107 | 1.2.8.4 | Run high pressure hoses x 2 + power cable |  | 15d | 2013-11-05 | 2013-11-25 | 96, 97, 106 | 124d | 0d |  | Hall | 120h |
| 108 | 1.2.8.5 | Fit West Mezz Walkway Sections |  | 3d | 2013-11-26 | 2013-11-28 | 107 | 124d | 0d |  | Hall | 24h |
| 109 | 1.2.8.6 | Commisioning |  | 10d | 2013-11-29 | 2013-12-12 | 108 | 124d | 0d |  | IM; AG | 160h |
| 110 | 1.2.8.7 | Sign Off / Complete | milestone | 0d | 2013-12-12 | 2013-12-12 | 109 | 124d |  |  | IM; AG |  |
| 111 | 1.3 | **New MLCR & rack room** |  | 186d | 2012-10-22 | 2013-07-08 |  | 237d |  |  |  | 2272h |
| 112 | 1.3.1 | **Design** |  | 61d | 2012-10-22 | 2013-01-14 |  | 284d |  |  |  | 664h |
| 113 | 1.3.1.1 | Concept Design |  | 5d | 2012-10-22 | 2012-10-26 |  | 284d | 0d | start no earlier than 2012-10-22 | JW; JT | 80h |
| 114 | 1.3.1.2 | 3D Model (detail) |  | 15d | 2012-10-29 | 2012-11-16 | 113 | 284d | 0d |  | LF; JT | 240h |
| 115 | 1.3.1.3 | Rack and workstation layout drawings |  | 3d | 2012-11-19 | 2012-11-21 | 114 | 316d | 0d |  | LF | 24h |
| 116 | 1.3.1.4 | Services instalation drawings |  | 5d | 2012-11-22 | 2012-11-28 | 115 | 395d |  |  | JW | 40h |
| 117 | 1.3.1.5 | Services management drawings |  | 5d | 2012-11-22 | 2012-11-28 | 115 | 316d | 32d |  | LF | 40h |
| 118 | 1.3.1.6 | Buildings Drawings |  | 30d | 2012-11-19 | 2012-12-28 | 114 | 284d | 0d |  | BPG | 240h |
| 119 | 1.3.1.7 | Experimental Halls Commitee Approval |  | 10d | 2012-12-31 | 2013-01-11 | 118 | 363d |  |  |  |  |
| 120 | 1.3.1.8 | SHE Approval |  | 10d | 2012-12-31 | 2013-01-11 | 118 | 284d | 0d |  |  |  |
| 121 | 1.3.1.9 | TB Approval |  | 1d | 2013-01-14 | 2013-01-14 | 117, 120 | 284d | 0d |  |  |  |
| 122 | 1.3.1.10 | Complete | milestone | 0d | 2013-01-14 | 2013-01-14 | 121 | 284d | 0d |  |  |  |
| 123 | 1.3.2 | **Buildings Work (MLCR)** |  | 105d | 2013-02-12 | 2013-07-08 |  | 237d |  |  |  | 744h |
| 124 | 1.3.2.1 | RFQ |  | 10d | 2013-02-12 | 2013-02-25 |  | 237d | 0d |  | BPG | 80h |
| 125 | 1.3.2.2 | Order |  | 3d | 2013-02-26 | 2013-02-28 | 124 | 237d | 0d |  | BPG | 24h |
| 126 | 1.3.2.3 | Contractor Lag |  | 30d | 2013-03-01 | 2013-04-11 | 125 | 237d | 0d |  |  |  |
| 127 | 1.3.2.4 | Services moves |  | 10d | 2013-04-12 | 2013-04-25 | 126 | 237d | 0d |  | Contractor | 80h |
| 128 | 1.3.2.5 | Door moves & install |  | 20d | 2013-04-26 | 2013-05-23 | 127 | 237d | 0d |  | Contractor | 160h |
| 129 | 1.3.2.6 | New signage etc |  | 2d | 2013-05-24 | 2013-05-27 | 128 | 237d | 0d |  | Contractor | 16h |
| 130 | 1.3.2.7 | Snagging |  | 5d | 2013-05-28 | 2013-06-03 | 129 | 237d | 0d |  | BPG; JT; Contractor | 120h |
| 131 | 1.3.2.8 | Office / Rack Room Builds |  | 15d | 2013-06-04 | 2013-06-24 | 130 | 237d | 0d |  | Contractor | 120h |
| 132 | 1.3.2.9 | False Floor Install |  | 10d | 2013-06-25 | 2013-07-08 | 131 | 237d |  |  | Contractor | 80h |
| 133 | 1.3.2.10 | Wall drilling to Hall |  | 3d | 2013-04-26 | 2013-04-30 | 127 | 281d | 0d |  | Contractor | 24h |
| 134 | 1.3.2.11 | Hall services ducts and channels |  | 5d | 2013-05-01 | 2013-05-07 | 133 | 281d | 34d |  | Contractor | 40h |
| 135 | 1.3.2.12 | Complete | milestone | 0d | 2013-06-24 | 2013-06-24 | 131, 134 | 247d |  |  |  |  |

| ID | WBS | Task | Type | Duration | Start | Finish | Predecessors | Total slack | Free slack | Resources | Work |
| --- | --- | --- | --- | --- | --- | --- | --- | --- | --- | --- | --- |
| 136 | 1.3.3 | **Services Management** |  | 50d | 2013-01-15 | 2013-03-25 |  | 284d |  |  | 640h |
| 137 | 1.3.3.1 | Order Services Management |  | 30d | 2013-01-15 | 2013-02-25 | 122 | 284d | 0d | JW; IM | 480h |
| 138 | 1.3.3.2 | Install cable tray & ductwork |  | 20d | 2013-02-26 | 2013-03-25 | 137 | 284d | 0d | Hall | 160h |
| 139 | 1.3.3.3 | Sign Off / Complete | milestone | 0d | 2013-03-25 | 2013-03-25 | 138 | 284d | 0d |  |  |
| 140 | 1.3.4 | **MLCR & Rack Room Prep** |  | 28d | 2013-03-26 | 2013-05-02 |  | 284d |  |  | 224h |
| 141 | 1.3.4.1 | Install Power & other services |  | 20d | 2013-03-26 | 2013-04-22 | 139 | 284d | 0d | Hall | 160h |
| 142 | 1.3.4.2 | Cabling and Networking |  | 5d | 2013-04-23 | 2013-04-29 | 141 | 284d | 0d | CM | 40h |
| 143 | 1.3.4.3 | Move Desks & computers |  | 2d | 2013-04-30 | 2013-05-01 | 142 | 284d | 0d | All | 16h |
| 144 | 1.3.4.4 | Commision |  | 1d | 2013-05-02 | 2013-05-02 | 143 | 284d | 0d | CM | 8h |
| 145 | 1.3.4.5 | Sign Off / Complete | milestone | 0d | 2013-05-02 | 2013-05-02 | 144 | 284d |  |  |  |
| 146 | 1.4 | **Tracker** |  | 166d | 2013-02-12 | 2013-10-01 |  | 176d |  |  | 1912h |
| 147 | 1.4.1 | Learn & Design Cryostat sub-model |  | 30d | 2013-02-12 | 2013-03-25 |  | 176d | 0d | KM | 240h |
| 148 | 1.4.2 | **Cryostat Local shields** |  | 136d | 2013-03-26 | 2013-10-01 |  | 176d | 0d |  | 1152h |
| 149 | 1.4.2.1 | **AFE PCB 1553 transformer** |  | 18d | 2013-03-26 | 2013-04-18 | 147 | 176d | 0d |  | 72h |
| 150 | 1.4.2.1.1 | Get AFE PCB & tracker rack test set-up in new room? |  | 2d | 2013-03-26 | 2013-03-27 |  | 176d | 0d | CM | 16h |
| 151 | 1.4.2.1.2 | Evaluate sensitivity with PM |  | 1d | 2013-03-28 | 2013-03-28 | 150 | 176d | 0d | CM; DA | 16h |
| 152 | 1.4.2.1.3 | Acquire suitable shield can and mount on PCB |  | 1d | 2013-03-29 | 2013-03-29 | 151 | 176d | 0d | CM | 8h |
| 153 | 1.4.2.1.4 | Test shield can |  | 2d | 2013-04-01 | 2013-04-02 | 152 | 176d | 0d | CM | 16h |
| 154 | 1.4.2.1.5 | Order cans |  | 10d | 2013-04-03 | 2013-04-16 | 153 | 176d | 0d |  |  |
| 155 | 1.4.2.1.6 | Assemble cans on PCB x16+ |  | 2d | 2013-04-17 | 2013-04-18 | 154 | 176d |  | CM | 16h |
| 156 | 1.4.2.2 | **Cold head** |  | 36d | 2013-04-18 | 2013-06-07 | 149 | 176d | 0d |  | 272h |
| 157 | 1.4.2.2.1 | Ferrous mass from Sumitomo | milestone | 0d | 2013-04-18 | 2013-04-18 |  | 176d | 0d | CM |  |
| 158 | 1.4.2.2.2 | Design split shielding can for motor |  | 2d | 2013-04-19 | 2013-04-22 | 157 | 176d | 0d | Design | 16h |
| 159 | 1.4.2.2.3 | Prototype shield manufacture? |  | 20d | 2013-04-23 | 2013-05-20 | 158 | 176d | 0d | OM | 160h |
| 160 | 1.4.2.2.4 | Set up cryo, vac & compressor test (3phase & water) |  | 3d | 2013-04-19 | 2013-04-23 |  | 195d | 19d | CM | 24h |
| 161 | 1.4.2.2.5 | Test prototype shield with PM or AFC? |  | 5d | 2013-05-21 | 2013-05-27 | 160, 159 | 176d | 0d | CM | 40h |
| 162 | 1.4.2.2.6 | How to test mag field effect on 2 stage shaft? |  | 5d | 2013-05-28 | 2013-06-03 | 160, 161 | 176d | 0d |  |  |
| 163 | 1.4.2.2.7 | Assemble shields on cold heads x4 |  | 4d | 2013-06-04 | 2013-06-07 | 162 | 176d |  | CM | 32h |

| ID | WBS | Task | Duration | Start | Finish | Predecessors | Total slack | Free slack | Resources | Work |
| --- | --- | --- | --- | --- | --- | --- | --- | --- | --- | --- |
| 164 | 1.4.2.3 | **Lid heater box** | 5d | 2013-06-10 | 2013-06-14 | 156 | 176d | 0d |  | 104h |
| 165 | 1.4.2.3.1 | Model & Test location to see if OK!? | 4d | 2013-06-10 | 2013-06-13 | 147 | 177d |  | KM; CM | 64h |
| 166 | 1.4.2.3.2 | Move to shielded location. Turbo control location or Tracker rack? | 5d | 2013-06-10 | 2013-06-14 |  | 176d |  | CM | 40h |
| 167 | 1.4.2.4 | **Turbo controller & PSU** | 5d | 2013-06-17 | 2013-06-21 | 164 | 176d | 0d |  | 112h |
| 168 | 1.4.2.4.1 | Test 8M cable | 2d | 2013-06-17 | 2013-06-18 | 160 | 177d | 0d | CM | 16h |
| 169 | 1.4.2.4.2 | Find shielded location for these units (Tr. Rack reach?) | 2d | 2013-06-19 | 2013-06-20 | 168 | 177d |  | CM | 16h |
| 170 | 1.4.2.4.3 | Or shield locally? | 5d | 2013-06-17 | 2013-06-21 |  | 176d |  | KM; Design | 80h |
| 171 | 1.4.2.5 | **CCG vacuum gauge** | 6d | 2013-06-24 | 2013-07-01 | 167 | 176d | 0d |  | 48h |
| 172 | 1.4.2.5.1 | Design/source shielding can | 3d | 2013-06-24 | 2013-06-26 |  | 176d | 0d | CM | 24h |
| 173 | 1.4.2.5.2 | Test shielding can with AFC? | 3d | 2013-06-27 | 2013-07-01 | 172 | 176d |  | CM | 24h |
| 174 | 1.4.2.6 | **Wiener PSU** | 28d | 2013-07-02 | 2013-08-08 | 171 | 176d | 0d |  | 224h |
| 175 | 1.4.2.6.1 | Cost MARATON range? | 1d | 2013-07-02 | 2013-07-02 |  | 203d |  |  |  |
| 176 | 1.4.2.6.2 | Design shield | 5d | 2013-07-02 | 2013-07-08 |  | 176d | 0d | Design | 40h |
| 177 | 1.4.2.6.3 | Manufacture shield | 20d | 2013-07-09 | 2013-08-05 | 176 | 176d | 0d | OM | 160h |
| 178 | 1.4.2.6.4 | Test shield with AFC? | 3d | 2013-08-06 | 2013-08-08 | 177 | 176d |  | CM | 24h |
| 179 | 1.4.2.7 | **Backing pump** | 5d | 2013-08-09 | 2013-08-15 | 174 | 176d | 0d |  | 56h |
| 180 | 1.4.2.7.1 | Test sensitivity of Diaphragm pump | 2d | 2013-08-09 | 2013-08-12 |  | 179d |  | CM | 16h |
| 181 | 1.4.2.7.2 | Result move or ok as is? | 5d | 2013-08-09 | 2013-08-15 |  | 176d |  | CM | 40h |
| 182 | 1.4.2.8 | **Turbo pump** | 28d | 2013-08-16 | 2013-09-24 | 179 | 176d | 0d |  | 224h |
| 183 | 1.4.2.8.1 | Design shielding cylinder | 5d | 2013-08-16 | 2013-08-22 |  | 176d | 0d | Design | 40h |
| 184 | 1.4.2.8.2 | Manufacture shield | 20d | 2013-08-23 | 2013-09-19 | 183 | 176d | 0d | OM | 160h |
| 185 | 1.4.2.8.3 | Test shield | 3d | 2013-09-20 | 2013-09-24 | 184 | 176d |  | CM | 24h |
| 186 | 1.4.2.9 | **Vac power fail solenoid** | 5d | 2013-09-25 | 2013-10-01 | 182 | 176d |  |  | 40h |
| 187 | 1.4.2.9.1 | Investigate non field sensitive alternative & design in | 5d | 2013-09-25 | 2013-10-01 |  | 176d |  | CM | 40h |

| ID | WBS | Task | Type | Duration | Start | Finish | Predecessors | Total slack | Free slack | Resources | Work |
| --- | --- | --- | --- | --- | --- | --- | --- | --- | --- | --- | --- |
| 188 | 1.4.3 | **Cryostat Big shield alternative** |  | 65d | 2013-03-26 | 2013-06-24 |  | 247d | 71d |  | 520h |
| 189 | 1.4.3.1 | Design Cryostat big shield model |  | 10d | 2013-03-26 | 2013-04-08 | 147 | 247d | 0d | KM | 80h |
| 190 | 1.4.3.2 | Engineer Cryostat big shield |  | 20d | 2013-04-09 | 2013-05-06 | 189 | 247d | 0d | Design | 160h |
| 191 | 1.4.3.3 | Manufacture Cryostat big shield |  | 30d | 2013-05-07 | 2013-06-17 | 190 | 247d | 0d | OM | 240h |
| 192 | 1.4.3.4 | Test Cryostat big shield |  | 5d | 2013-06-18 | 2013-06-24 | 191 | 247d |  | Test | 40h |
| 193 | 1.4.4 | **Other Tracker issues** |  | 2d | 2013-02-12 | 2013-02-13 |  | 340d | 164d |  |  |
| 194 | 1.4.4.1 | Vesda |  | 2d | 2013-02-12 | 2013-02-13 |  | 340d |  |  |  |
| 195 | 1.4.4.2 | UKUS mains transformer |  | 2d | 2013-02-12 | 2013-02-13 |  | 340d |  |  |  |
| 196 | 1.4.5 | Tracker field mitigation complete | milestone | 0d | 2013-10-01 | 2013-10-01 | 198, 148, 188, 193 | 176d |  |  |  |
| 197 | 1.5 | **Racks** |  | 36d | 2013-02-12 | 2013-04-02 |  | 306d |  |  | 232h |
| 198 | 1.5.1 | **Tracker** |  | 31d | 2013-02-12 | 2013-03-26 |  | 311d | 135d |  | 128h |
| 199 | 1.5.1.1 | Design Tracker racks sub-model |  | 5d | 2013-03-13 | 2013-03-19 | 9 | 306d | 0d | MG | 40h |
| 200 | 1.5.1.2 | Cost/Benefit to extend VLSB cables |  | 3d | 2013-02-12 | 2013-02-14 |  | 336d | 0d | Test | 24h |
| 201 | 1.5.1.3 | Decide location |  | 3d | 2013-02-15 | 2013-02-19 | 200 | 336d |  | Design | 24h |
| 202 | 1.5.1.4 | Shield? |  | 5d | 2013-03-20 | 2013-03-26 | 199 | 311d |  | Design | 40h |
| 203 | 1.5.2 | **HV** |  | 10d | 2013-03-20 | 2013-04-02 |  | 306d |  |  | 104h |
| 204 | 1.5.2.1 | Design HV racks sub-model |  | 5d | 2013-03-20 | 2013-03-26 | 199 | 306d | 0d | MG | 40h |
| 205 | 1.5.2.2 | Move to rack room or shield or both? |  | 2d | 2013-03-27 | 2013-03-28 | 204 | 306d | 0d | MG | 16h |
| 206 | 1.5.2.3 | Organise move, connect & test? |  | 3d | 2013-03-29 | 2013-04-02 | 205 | 306d |  | Hall; Test | 48h |
| 207 | 1.6 | **Power Supply** |  | 50d | 2013-02-12 | 2013-04-22 |  | 292d |  |  | 552h |
| 208 | 1.6.1 | **Substation 25** |  | 10d | 2013-02-12 | 2013-02-25 |  | 292d | 0d |  | 80h |
| 209 | 1.6.1.1 | Analyse content & model |  | 10d | 2013-02-12 | 2013-02-25 |  | 292d |  | Modeller | 80h |
| 210 | 1.6.2 | **Magnet power supplies** |  | 10d | 2013-02-26 | 2013-03-11 | 208 | 292d | 0d |  | 80h |
| 211 | 1.6.2.1 | Analyse content & model |  | 10d | 2013-02-26 | 2013-03-11 |  | 292d |  | Modeller | 80h |

| ID | WBS | Task | Duration | Start | Finish | Predecessors | Total slack | Free slack | Resources | Work |
| --- | --- | --- | --- | --- | --- | --- | --- | --- | --- | --- |
| 212 | 1.6.3 | **Trench transformer** | 5d | 2013-03-12 | 2013-03-18 | 210 | 292d | 0d |  | 40h |
| 213 | 1.6.3.1 | Analyse content & model | 5d | 2013-03-12 | 2013-03-18 |  | 292d |  | Modeller | 40h |
| 214 | 1.6.4 | **Distribution boards** | 5d | 2013-03-19 | 2013-03-25 | 212 | 292d | 0d |  | 48h |
| 215 | 1.6.4.1 | Analyse content & model | 5d | 2013-03-19 | 2013-03-25 |  | 292d |  | Modeller | 40h |
| 216 | 1.6.4.2 | Decide which units at risk? | 1d | 2013-03-19 | 2013-03-19 |  | 296d |  | Modeller | 8h |
| 217 | 1.6.5 | **Consumer unit MCB/RCD issues** | 5d | 2013-03-26 | 2013-04-01 | 214 | 292d | 0d |  | 64h |
| 218 | 1.6.5.1 | Analyse content & model | 5d | 2013-03-26 | 2013-04-01 |  | 292d |  | Modeller | 40h |
| 219 | 1.6.5.2 | Test in AFC field? | 2d | 2013-03-26 | 2013-03-27 |  | 295d |  | Test | 16h |
| 220 | 1.6.5.3 | Decide which units at risk? | 1d | 2013-03-26 | 2013-03-26 |  | 296d |  | Modeller | 8h |
| 221 | 1.6.6 | Power supply consequences? | 15d | 2013-04-02 | 2013-04-22 | 217 | 292d |  | Design; Test | 240h |
| 222 | 1.7 | **Cooling channel sensitive components?** | 1d? | 2013-02-12 | 2013-02-12 |  | 341d |  |  | 24h |
| 223 | 1.7.1 | **Spectrometer solenoid** | 1d? | 2013-02-12 | 2013-02-12 |  | 341d |  |  | 8h |
| 224 | 1.7.1.1 | Cryocoolers | 1d? | 2013-02-12 | 2013-02-12 |  | 341d |  | Groups | 8h |
| 225 | 1.7.2 | AFC | 1d? | 2013-02-12 | 2013-02-12 |  | 341d |  | Groups | 8h |
| 226 | 1.7.3 | RF | 1d? | 2013-02-12 | 2013-02-12 |  | 341d |  | Groups | 8h |
| 227 | 1.8 | **Detectors** | 1d? | 2013-02-12 | 2013-02-12 |  | 341d |  |  | 24h |
| 228 | 1.8.1 | **KL** | 1d? | 2013-02-12 | 2013-02-12 |  | 341d |  |  | 8h |
| 229 | 1.8.1.1 | Gather info & model? | 1d? | 2013-02-12 | 2013-02-12 |  | 341d |  | Groups | 8h |
| 230 | 1.8.2 | **EMR** | 1d? | 2013-02-12 | 2013-02-12 |  | 341d |  |  | 8h |
| 231 | 1.8.2.1 | Gather info & model? | 1d? | 2013-02-12 | 2013-02-12 |  | 341d |  | Groups | 8h |
| 232 | 1.8.3 | **TOF** | 1d? | 2013-02-12 | 2013-02-12 |  | 341d |  |  | 8h |
| 233 | 1.8.3.1 | Gather info & model? | 1d? | 2013-02-12 | 2013-02-12 |  | 341d |  | Groups | 8h |
| 234 | 1.9 | **Othert Equipment** | 8d | 2013-02-12 | 2013-02-21 |  | 334d |  |  | 216h |
| 235 | 1.9.1 | **LH2 Vacuum pumps & others?** | 5d | 2013-02-12 | 2013-02-18 |  | 337d |  |  | 64h |
| 236 | 1.9.1.1 | Model | 5d | 2013-02-12 | 2013-02-18 |  | 337d |  | Modeller | 40h |
| 237 | 1.9.1.2 | Test sensitivity? | 3d | 2013-02-12 | 2013-02-14 |  | 339d |  | Test | 24h |

| ID | WBS | Task | Type | Duration | Start | Finish | Predecessors | Total slack | Free slack | Constraint | Resources | Work |
| --- | --- | --- | --- | --- | --- | --- | --- | --- | --- | --- | --- | --- |
| 238 | 1.9.2 | **PPS** |  | 8d | 2013-02-12 | 2013-02-21 |  | 334d |  |  |  | 64h |
| 239 | 1.9.2.1 | Model PPS racks |  | 5d | 2013-02-12 | 2013-02-18 |  | 334d | 0d |  | Modeller | 40h |
| 240 | 1.9.2.2 | Test sensitivity? |  | 3d | 2013-02-19 | 2013-02-21 | 239 | 334d |  |  | CM | 24h |
| 241 | 1.9.3 | **Linde Fridge** |  | 5d | 2013-02-12 | 2013-02-18 |  | 337d |  |  |  | 56h |
| 242 | 1.9.3.1 | Model |  | 5d | 2013-02-12 | 2013-02-18 |  | 337d |  |  | Modeller | 40h |
| 243 | 1.9.3.2 | AFC test in hall? |  | 2d | 2013-02-12 | 2013-02-13 |  | 340d |  |  | Test | 16h |
| 244 | 1.9.4 | **Moving beam stop** |  | 2d | 2013-02-12 | 2013-02-13 |  | 340d |  |  |  | 32h |
| 245 | 1.9.4.1 | Model |  | 2d | 2013-02-12 | 2013-02-13 |  | 340d |  |  | Modeller | 16h |
| 246 | 1.9.4.2 | AFC test in hall? |  | 2d | 2013-02-12 | 2013-02-13 |  | 340d |  |  | Test | 16h |
| 247 | 1.9.5 | Other? |  | 2d | 2013-02-12 | 2013-02-13 |  | 340d |  |  |  |  |
| 248 | 1.10 | **Infrastructure** |  | 20d | 2013-02-12 | 2013-03-11 |  | 322d |  |  |  | 240h |
| 249 | 1.10.1 | Fire protection |  | 3d | 2013-02-12 | 2013-02-14 |  | 322d | 0d |  | Test | 24h |
| 250 | 1.10.2 | Lighting |  | 2d | 2013-02-15 | 2013-02-18 | 249 | 322d | 0d |  | Test | 16h |
| 251 | 1.10.3 | Aircon units & fans |  | 3d | 2013-02-19 | 2013-02-21 | 250 | 322d | 0d |  | Test | 24h |
| 252 | 1.10.4 | Crane |  | 2d | 2013-02-22 | 2013-02-25 | 251 | 322d | 0d |  | Test | 16h |
| 253 | 1.10.5 | Consequences? |  | 10d | 2013-02-26 | 2013-03-11 | 252 | 322d |  |  | Design; Test | 160h |
| 254 | 1.11 | **Area study** |  | 24d | 2013-02-19 | 2013-03-22 | 6 | 313d |  |  |  | 272h |
| 255 | 1.11.1 | **ISIS Areas** |  | 6d | 2013-02-19 | 2013-02-26 |  | 313d | 0d |  |  | 48h |
| 256 | 1.11.1.1 | LCR, Diagnostics & Plant room |  | 2d | 2013-02-19 | 2013-02-20 |  | 313d | 0d |  | PS | 16h |
| 257 | 1.11.1.2 | ISIS beam chopper rack, Linac, Ion source? |  | 2d | 2013-02-21 | 2013-02-22 | 256 | 313d | 0d |  | PS | 16h |
| 258 | 1.11.1.3 | Put forward document to ISIS |  | 2d | 2013-02-25 | 2013-02-26 | 257 | 313d |  |  | PS | 16h |
| 259 | 1.11.2 | New rack room |  | 2d | 2013-02-27 | 2013-02-28 | 255 | 313d | 0d |  | PS | 16h |
| 260 | 1.11.3 | New MLCR |  | 2d | 2013-03-01 | 2013-03-04 | 259 | 313d | 0d |  | PS | 16h |
| 261 | 1.11.4 | LH2 south mezz |  | 2d | 2013-03-05 | 2013-03-06 | 260 | 313d | 0d |  | PS | 16h |
| 262 | 1.11.5 | Equipment on roof |  | 2d | 2013-03-07 | 2013-03-08 | 261 | 313d | 0d |  | PS | 16h |
| 263 | 1.11.6 | Area study consequences? |  | 10d | 2013-03-11 | 2013-03-22 | 262 | 313d |  |  | Design; Test | 160h |
| 264 | 1.12 | Step4 ready to run | milestone | 0d | 2014-06-04 | 2014-06-04 |  | 0d |  | finish no earlier than 2014-06-04 |  |  |
| 266 | 1.13 | Resources | milestone | 0d | 2013-02-12 | 2013-02-12 |  | 342d |  |  | Holger; Mike; Vicky; Victoria; Ian; Celeste; Steve Grad 6M 50%? |  |
